# Kicker Shutdown Tasks

Schedule from MS Project, 2008-12-01 to 2009-10-23.
Fermilab

## Calendars

- Standard: Mon-Fri 08:00-12:00, 13:00-17:00; Sat-Sun off. Exceptions (off unless hours are given): 2008-12-24 to 2008-12-25, 2008-12-31 to 2009-01-01, 2009-01-19, 2009-05-25, 2009-07-03, 2009-09-07.

## Resources

| Resource |
| --- |
| AD Mechanical Technician |
| PPD Survey |
| Electricians |
| Pipe Fitters |
| AD Mechanical Engineer |
| AD Mechanical Drafter |
| AD Electrical Technician |
| Carpenters |
| AD Radiation Technician |

## Schedule

| ID | WBS | Task | Duration | Start | Finish | Predecessors | Total slack | Free slack | Constraint | Resources | Work |
| --- | --- | --- | --- | --- | --- | --- | --- | --- | --- | --- | --- |
| 1 | 1 | **Kickers** | 13d | 2009-06-15 | 2009-07-01 |  | 36d |  |  |  | 544h |
| 2 | 1.1 | Remove Existing MI Beampipe & Flange | 5d | 2009-06-15 | 2009-06-19 | 180 | 36d | 0d |  | AD Mechanical Technician [200%] | 80h |
| 3 | 1.2 | Stand Installation | 3d | 2009-06-15 | 2009-06-17 | 180 | 38d | 2d |  | AD Mechanical Technician [300%]; PPD Survey [200%] | 120h |
| 4 | 1.3 | Install Magnets | 7d | 2009-06-22 | 2009-06-30 | 2, 3 | 36d | 0d |  | AD Mechanical Technician [400%] | 224h |
| 5 | 1.4 | Survey & Vacuum Leak Check | 3d | 2009-06-22 | 2009-06-24 | 2 | 41d |  |  | AD Mechanical Technician [200%]; PPD Survey [200%] | 96h |
| 6 | 1.5 | Kicker Cable Tray Installation | 1d | 2009-06-15 | 2009-06-15 | 180 | 48d |  |  | Electricians | 8h |
| 7 | 1.6 | Fluorinert Pipe Install, Long Run | 1d | 2009-06-15 | 2009-06-15 | 180 | 48d |  |  | Pipe Fitters | 8h |
| 8 | 1.7 | Fluorinert Pipe Install, Manifold | 1d | 2009-07-01 | 2009-07-01 | 4 | 36d |  |  | Pipe Fitters | 8h |
| 9 | 2 | **Civil** | 226.45d | 2008-12-01 | 2009-10-23 |  | 0d |  |  |  | 1337.6h |
| 10 | 2.1 | **General** | 61d | 2008-12-01 | 2009-03-02 |  | 66d |  |  |  |  |
| 11 | 2.1.1 | Funds Available, Bid Package Ready and Out for Bid | 1d | 2008-12-01 | 2008-12-01 |  | 66d | 0d | start no earlier than 2008-12-01 |  |  |
| 12 | 2.1.2 | Receive Bids | 30d | 2008-12-02 | 2009-01-16 | 11 | 66d | 0d |  |  |  |
| 13 | 2.1.3 | Award Civil Contract/NTP/Authorization to Order Long Lead Items | 30d | 2009-01-20 | 2009-03-02 | 12 | 66d |  |  |  |  |
| 14 | 2.2 | **Tunnel Work** | 92.45d | 2009-06-15 | 2009-10-23 |  | -43.45d | 0d |  |  | 1337.6h |
| 15 | 2.2.1 | **MI-39 Region** | 92.45d | 2009-06-15 | 2009-10-23 |  | -43.45d | 0d |  |  | 867.6h |
| 16 | 2.2.1.1 | **Fermi @ MI-39** | 92.45d | 2009-06-15 | 2009-10-23 |  | -43.45d | 0d |  |  | 867.6h |
| 17 | 2.2.1.1.1 | Shift Electricians, Equipment | 1d | 2009-06-15 | 2009-06-15 | 180 | -10d | 0d |  | Electricians [400%]; AD Mechanical Technician [50%] | 36h |
| 18 | 2.2.1.1.2 | Blanket Magnets | 1d | 2009-06-15 | 2009-06-15 | 180 | -10d | 0d |  |  |  |
| 19 | 2.2.1.1.3 | Jack-up, Shift Cable Tray for Temporary Position | 2d | 2009-06-16 | 2009-06-17 | 18, 17 | -10d | 0d |  | Electricians [400%]; AD Mechanical Technician [50%] | 72h |
| 20 | 2.2.1.1.4 | Re-run any 110/220/480 Lines to Final Location | 1d | 2009-08-18 | 2009-08-19 | 86 | -1.95d | 0d |  | Electricians [400%]; AD Mechanical Technician [50%] | 36h |
| 21 | 2.2.1.1.5 | Extend any Cabling as Necessary | 1d | 2009-08-19 | 2009-08-20 | 20 | -1.95d | 0d |  | Electricians [400%]; AD Mechanical Technician [50%] | 36h |
| 22 | 2.2.1.1.6 | Mount Cable Tray in Final Location | 2d | 2009-08-20 | 2009-08-24 | 21 | -1.95d | 0d |  | Electricians [400%]; AD Mechanical Technician [50%] | 72h |
| 23 | 2.2.1.1.7 | Clean-up, Destage, Remove Equipment from Tunnel Area | 1d | 2009-08-24 | 2009-08-25 | 117, 22 | -1.95d | 0d |  | Electricians [400%]; AD Mechanical Technician [50%] | 36h |
| 24 | 2.2.1.1.8 | Fermilab Grade Survey before Beam Turn-on | 1d | 2009-09-22 | 2009-09-23 | 100 | -21.95d | 0d |  |  |  |
| 25 | 2.2.1.1.9 | As-found survey MI and RR Q341 to Q404 | 3d | 2009-06-15 | 2009-06-17 | 180 | -2.95d | 0d |  | PPD Survey | 24h |
| 26 | 2.2.1.1.10 | Close beam valve at MI Q400 | 0.1d | 2009-06-18 | 2009-06-18 | 25 | -2.95d | 0d |  | AD Mechanical Technician | 0.8h |
| 27 | 2.2.1.1.11 | Vent up MI at Q401 | 0.4d | 2009-06-18 | 2009-06-18 | 26 | -2.95d | 0d |  | AD Mechanical Technician | 3.2h |
| 28 | 2.2.1.1.12 | Cut beam tube | 0.2d | 2009-06-18 | 2009-06-18 | 27 | -2.95d | 0d |  | AD Mechanical Technician | 1.6h |
| 29 | 2.2.1.1.13 | Weld in Conflat flanges | 0.5d | 2009-06-18 | 2009-06-19 | 28 | -2.95d | 0d |  | AD Mechanical Technician | 4h |
| 30 | 2.2.1.1.14 | Install Beam Valve | 0.5d | 2009-06-19 | 2009-06-19 | 29 | -2.95d | 0d |  | AD Mechanical Technician | 4h |
| 31 | 2.2.1.1.15 | Leak check both sides | 1d | 2009-06-19 | 2009-06-22 | 30 | -2.95d | 0d |  | AD Mechanical Technician | 8h |
| 32 | 2.2.1.1.16 | Backfill with dry nitrogen? | 0.5d | 2009-06-22 | 2009-06-23 | 31 | -2.95d | 0d |  | AD Mechanical Technician | 4h |
| 33 | 2.2.1.1.17 | Install lead blanket support stands on Lambertsons at MI Q401 | 2d | 2009-06-23 | 2009-06-25 | 32 | -2.95d | 0d |  | AD Mechanical Technician | 16h |
| 34 | 2.2.1.1.18 | Install lead blankets on Lambertsons at MI Q401 | 2d | 2009-06-25 | 2009-06-29 | 33 | -2.95d | 0d |  | AD Mechanical Technician | 16h |
| 35 | 2.2.1.1.19 | Disconnect cables from kicker magnets at Q400 | 0.25d | 2009-06-29 | 2009-06-29 | 34 | -2.95d | 0d |  | AD Electrical Technician | 2h |
| 36 | 2.2.1.1.20 | Fold cables back towards MI40 | 0.5d | 2009-06-29 | 2009-06-29 | 35 | -2.95d | 0d |  | AD Electrical Technician | 4h |
| 37 | 2.2.1.1.21 | Remove cable trays Q401 to Q403 | 0.5d | 2009-06-29 | 2009-06-30 | 36 | -2.95d | 0d |  | AD Electrical Technician | 4h |
| 38 | 2.2.1.1.22 | Wrap MI magnets and beam tube with Herculite Q401 to Q403 | 2d | 2009-06-30 | 2009-07-02 | 37 | -2.95d | 0d |  | AD Mechanical Technician | 16h |
| 39 | 2.2.1.1.23 | Wrap Recycler magnets and beam tube with Herculite Q401 to Q403 | 2d | 2009-07-02 | 2009-07-07 | 38 | -2.95d | 0d |  | AD Mechanical Technician | 16h |
| 40 | 2.2.1.1.24 | Build barrier wall between Q401 and Lambertson, wood & herculite | 2d | 2009-07-07 | 2009-07-09 | 39 | -2.95d | 0d |  | Carpenters | 16h |
| 41 | 2.2.1.1.25 | Build barrier wall between Lambertson and Q403, wood & herculite | 2d | 2009-07-09 | 2009-07-13 | 40 | -2.95d | 0d |  | Carpenters | 16h |
| 42 | 2.2.1.1.26 | Install ventilation hose in barrier wall and feeding up MI-40 stairway | 1d | 2009-07-13 | 2009-07-14 | 41 | -2.95d | 0d |  | AD Mechanical Technician | 8h |
| 43 | 2.2.1.1.27 | Install fan in ventilation hose at MI-40 | 0.5d | 2009-07-14 | 2009-07-14 | 42 | -2.95d | 0d |  | AD Mechanical Technician | 4h |
| 44 | 2.2.1.1.28 | Install 6 drain spouts on ceiling to catch coring water | 3d | 2009-07-14 | 2009-07-17 | 43 | -2.95d | 0d |  | AD Mechanical Technician | 24h |
| 45 | 2.2.1.1.29 | Bring 55 gal barrels | 1d | 2009-07-17 | 2009-07-20 | 44 | -2.95d | 0d |  | AD Radiation Technician | 8h |
| 46 | 2.2.1.1.30 | Install drainage ducts from spouts to 55 gal barrels | 1d | 2009-07-20 | 2009-07-21 | 45 | -2.95d | 0d |  | AD Mechanical Technician | 8h |
| 47 | 2.2.1.1.31 | Install Fluorinert piping in tunnel | 10d | 2009-08-18 | 2009-09-01 | 84 | -43.45d | 0d |  | Pipe Fitters | 80h |
| 48 | 2.2.1.1.32 | Remove 55 gal barrels from MI-40 work zone | 1d | 2009-09-01 | 2009-09-02 | 47 | -43.45d | 0d |  | AD Mechanical Technician | 8h |
| 49 | 2.2.1.1.33 | Remove drainage ducts from spouts | 0.25d | 2009-09-02 | 2009-09-03 | 48 | -43.45d | 0d |  | AD Mechanical Technician | 2h |
| 50 | 2.2.1.1.34 | Remove 6 drain spouts | 0.75d | 2009-09-03 | 2009-09-03 | 49 | -43.45d | 0d |  | AD Mechanical Technician | 6h |
| 51 | 2.2.1.1.35 | Cleanup ceiling | 0.5d | 2009-09-03 | 2009-09-04 | 50 | -43.45d | 0d |  | AD Mechanical Technician | 4h |
| 52 | 2.2.1.1.36 | Install 8 shield covers on ceiling penetrations | 1d | 2009-09-04 | 2009-09-08 | 51 | -43.45d | 0d |  | AD Mechanical Technician | 8h |
| 53 | 2.2.1.1.37 | Fill 8 conduits with plastic beads | 1d | 2009-09-08 | 2009-09-09 | 52 | -43.45d | 0d |  | AD Mechanical Technician | 8h |
| 54 | 2.2.1.1.38 | Cleanup any major mess in barrier zone | 1d | 2009-09-09 | 2009-09-10 | 53 | -43.45d | 0d |  | AD Mechanical Technician | 8h |
| 55 | 2.2.1.1.39 | Remove barrier walls | 1d | 2009-09-10 | 2009-09-11 | 54 | -43.45d | 0d |  | AD Mechanical Technician | 8h |
| 56 | 2.2.1.1.40 | Remove ventilation hose | 0.25d | 2009-09-11 | 2009-09-11 | 55 | -43.45d | 0d |  | AD Mechanical Technician | 2h |
| 57 | 2.2.1.1.41 | Remove ventilation fan | 0.25d | 2009-09-11 | 2009-09-11 | 56 | -43.45d | 0d |  | AD Mechanical Technician | 2h |
| 58 | 2.2.1.1.42 | Cleanup any remaining concrete dust in barrier zone | 1d | 2009-09-11 | 2009-09-14 | 57 | -43.45d | 0d |  | AD Mechanical Technician | 8h |
| 59 | 2.2.1.1.43 | Remove herculite from Recycler beamline | 1d | 2009-09-14 | 2009-09-15 | 58 | -43.45d | 0d |  | AD Mechanical Technician | 8h |
| 60 | 2.2.1.1.44 | Remove herculite from MI beamline | 1d | 2009-09-15 | 2009-09-16 | 59 | -43.45d | 0d |  | AD Mechanical Technician | 8h |
| 61 | 2.2.1.1.45 | Cleanup any remaining concrete dust in work zone | 1d | 2009-09-16 | 2009-09-17 | 60 | -43.45d | 0d |  | AD Mechanical Technician | 8h |
| 62 | 2.2.1.1.46 | Reinstall cable trays | 3d | 2009-09-17 | 2009-09-22 | 61 | -43.45d | 0d |  | AD Electrical Technician | 24h |
| 63 | 2.2.1.1.47 | Fold cable back to kickers | 2d | 2009-09-22 | 2009-09-24 | 62 | -43.45d | 0d |  | AD Electrical Technician | 16h |
| 64 | 2.2.1.1.48 | Reinstall cable on kickers | 1d | 2009-09-24 | 2009-09-25 | 63 | -43.45d | 0d |  | AD Electrical Technician | 8h |
| 65 | 2.2.1.1.49 | Pull new cable for Gap Clearing kickers if ready | 3d | 2009-09-25 | 2009-09-30 | 64 | -43.45d | 0d |  | AD Electrical Technician | 24h |
| 66 | 2.2.1.1.50 | Install 6 kicker stands in short straight section Q400-401 | 1d | 2009-09-30 | 2009-10-01 | 65 | -43.45d | 0d |  | AD Mechanical Technician | 8h |
| 67 | 2.2.1.1.51 | Vent up short straight section Q400-401 | 0.5d | 2009-10-01 | 2009-10-02 | 66 | -43.45d | 0d |  | AD Mechanical Technician | 4h |
| 68 | 2.2.1.1.52 | Install 6 kickers in short straight section Q400-401 if ready | 3d | 2009-10-02 | 2009-10-07 | 67 | -43.45d | 0d |  | AD Mechanical Technician | 24h |
| 69 | 2.2.1.1.53 | Align new kickers | 1d | 2009-10-07 | 2009-10-08 | 68 | -43.45d | 0d |  | PPD Survey | 8h |
| 70 | 2.2.1.1.54 | Leak check short straight section Q400-401 | 2d | 2009-10-08 | 2009-10-12 | 69 | -43.45d | 0d |  | AD Mechanical Technician | 16h |

| ID | WBS | Task | Duration | Start | Finish | Predecessors | Total slack | Free slack | Resources | Work |
| --- | --- | --- | --- | --- | --- | --- | --- | --- | --- | --- |
| 71 | 2.2.1.1.55 | Connect cables to new kickers if ready | 1d | 2009-10-12 | 2009-10-13 | 70 | -43.45d | 0d | AD Electrical Technician | 8h |
| 72 | 2.2.1.1.56 | Remove lead blankets from Lambertsons | 1d | 2009-10-13 | 2009-10-14 | 71 | -43.45d | 0d | AD Mechanical Technician | 8h |
| 73 | 2.2.1.1.57 | Remove lead blanket support stands from Lambertsons | 1d | 2009-10-14 | 2009-10-15 | 72 | -43.45d | 0d | AD Mechanical Technician | 8h |
| 74 | 2.2.1.1.58 | Pump down MI 402 sector and leak check | 3d | 2009-10-15 | 2009-10-20 | 73 | -43.45d | 0d | AD Mechanical Technician | 24h |
| 75 | 2.2.1.1.59 | Align MI and RR Q341 to Q404 | 3d | 2009-10-20 | 2009-10-23 | 74 | -43.45d | 0d | PPD Survey | 24h |
| 76 | 2.2.1.2 | **Contractor @ MI-39** | 70.95d | 2009-06-15 | 2009-09-23 |  | -22.5d | 0d |  |  |
| 77 | 2.2.1.2.1 | **Conduit Installation** | 55.95d | 2009-06-15 | 2009-09-01 |  | -22.5d | 0d |  |  |
| 78 | 2.2.1.2.1.1 | Install Erosion Control | 1d | 2009-06-15 | 2009-06-15 | 180 | -22.5d | 0d |  |  |
| 79 | 2.2.1.2.1.2 | Clear & Grub | 2d | 2009-06-16 | 2009-06-17 | 78 | -22.5d | 0d |  |  |
| 80 | 2.2.1.2.1.3 | Strip & Stockpile Topsoil | 2d | 2009-06-18 | 2009-06-19 | 79 | -22.5d | 0d |  |  |
| 81 | 2.2.1.2.1.4 | Excavation of berm above Q401 to Q403 | 5d | 2009-07-21 | 2009-07-28 | 80, 19, 46 | -43.45d | 0d |  |  |
| 82 | 2.2.1.2.1.5 | Coring of 8 holes in ceiling | 10d | 2009-07-28 | 2009-08-11 | 81 | -43.45d | 0d |  |  |
| 83 | 2.2.1.2.1.6 | Install Support Frames | 10d | 2009-07-28 | 2009-08-11 | 82FF | -43.45d | 0d |  |  |
| 84 | 2.2.1.2.1.7 | Installation of 8 conduits | 10d | 2009-08-04 | 2009-08-18 | 83SS+5d | -43.45d | 0d |  |  |
| 85 | 2.2.1.2.1.8 | FBP Enclosure Cap Beams | 5d | 2009-08-04 | 2009-08-11 | 84SS | -21.95d | 0d |  |  |
| 86 | 2.2.1.2.1.9 | Waterproof at Top of Enclosure | 5d | 2009-08-11 | 2009-08-18 | 85 | -21.95d | 0d |  |  |
| 87 | 2.2.1.2.1.10 | Backfilling of berm above Q401 to Q403 | 10d | 2009-08-18 | 2009-09-01 | 86 | -21.95d | 0d |  |  |
| 88 | 2.2.1.2.2 | **Concrete Foundation Installation** | 25d | 2009-08-18 | 2009-09-23 |  | -21.95d | 0d |  |  |
| 89 | 2.2.1.2.2.1 | FBP Deep Footing | 5d | 2009-08-18 | 2009-08-25 | 87SS | -21.95d | 0d |  |  |
| 90 | 2.2.1.2.2.2 | FBP Deep Well | 5d | 2009-08-25 | 2009-09-01 | 89 | -21.95d | 0d |  |  |
| 91 | 2.2.1.2.2.3 | FBP Remaining Footings | 5d | 2009-08-25 | 2009-09-01 | 90SS | -21.95d | 0d |  |  |
| 92 | 2.2.1.2.2.4 | FBP Remaining Walls | 5d | 2009-09-01 | 2009-09-09 | 91 | -21.95d | 0d |  |  |
| 93 | 2.2.1.2.2.5 | Backfill & Install Under Slab Conduits | 5d | 2009-09-09 | 2009-09-16 | 92 | -21.95d | 0d |  |  |
| 94 | 2.2.1.2.2.6 | FBP Floor Slab | 5d | 2009-09-16 | 2009-09-23 | 93 | -21.95d | 0d |  |  |
| 95 | 2.2.1.2.2.7 | Construction of Foundations & Floor Slabs for MI-39 Bldg | 10d | 2009-08-18 | 2009-09-01 | 87SS | -6.95d | 0d |  |  |

| ID | WBS | Task | Duration | Start | Finish | Predecessors | Total slack | Free slack | Resources | Work |
| --- | --- | --- | --- | --- | --- | --- | --- | --- | --- | --- |
| 96 | 2.2.1.2.3 | **Utility Installation** | 24d | 2009-08-18 | 2009-09-22 |  | -21.95d | 0d |  |  |
| 97 | 2.2.1.2.3.1 | Installation Communication Handholes & Ductbank | 15d | 2009-08-18 | 2009-09-09 | 89SS | -15.95d | 0d |  |  |
| 98 | 2.2.1.2.3.2 | Install ICW Piping | 10d | 2009-08-25 | 2009-09-09 | 97FF | -15.95d | 0d |  |  |
| 99 | 2.2.1.2.3.3 | Install Storm Sewer Manholes & Piping | 21d | 2009-08-18 | 2009-09-17 | 87SS | -21.95d | 0d |  |  |
| 100 | 2.2.1.2.3.4 | Install Hardstand | 3d | 2009-09-17 | 2009-09-22 | 97, 98, 99 | -21.95d | 0d |  |  |
| 101 | 2.2.2 | **MI-14 Region** | 81.95d | 2009-06-15 | 2009-10-08 |  | -7d | 0d |  | 470h |
| 102 | 2.2.2.1 | **Fermi @ MI-14** | 81.95d | 2009-06-15 | 2009-10-08 |  | 10.5d |  |  | 470h |
| 103 | 2.2.2.1.1 | As-found Survey MI and RR Q102 to Q108 | 3d | 2009-06-15 | 2009-06-17 | 180 | 77.45d | 0d | PPD Survey | 24h |
| 104 | 2.2.2.1.2 | Install lead blanket support stands on magnets at MI Q103 | 2d | 2009-06-18 | 2009-06-19 | 103 | 77.45d | 0d | AD Mechanical Technician | 16h |
| 105 | 2.2.2.1.3 | Install lead blankets on magnets at MI Q103 | 2d | 2009-06-22 | 2009-06-23 | 104 | 77.45d | 0d | AD Mechanical Technician | 16h |
| 106 | 2.2.2.1.4 | Wrap MI Magnets & Beam Tube with Hervulite Q103 to Q107 | 2d | 2009-06-24 | 2009-06-25 | 105 | 77.45d | 0d | AD Mechanical Technician | 16h |
| 107 | 2.2.2.1.5 | Wrap Recycler Magnets & Beam Tube with Herculite Q103 to Q107 | 2d | 2009-06-26 | 2009-06-29 | 106 | 77.45d | 0d | AD Mechanical Technician | 16h |
| 108 | 2.2.2.1.6 | Build Barrier Wall Between Q103 & Q104, Wood & Herculite | 2d | 2009-06-30 | 2009-07-01 | 107 | 77.45d | 0d | Carpenters | 16h |
| 109 | 2.2.2.1.7 | Build Barrier Wall Between Q106 & Q107, Wood & Herculite | 2d | 2009-07-02 | 2009-07-06 | 108 | 77.45d |  | Carpenters | 16h |
| 110 | 2.2.2.1.8 | Install Ventilation Hose in Barrier Wall & Feeding up MI-14 Stairway | 1d | 2009-07-07 | 2009-07-07 | 109 | 69.95d | 0d | AD Mechanical Technician | 8h |
| 111 | 2.2.2.1.9 | Install Fan in Ventilation Hose at MI-14 | 0.5d | 2009-07-08 | 2009-07-08 | 110 | 69.95d | 0d | AD Mechanical Technician | 4h |
| 112 | 2.2.2.1.10 | Install 8 Drain Spouts on Ceiling to Catch Coring Water | 4d | 2009-07-08 | 2009-07-14 | 111 | 69.95d | 0d | AD Mechanical Technician | 32h |
| 113 | 2.2.2.1.11 | Bring 55 Gal Barrels | 1d | 2009-07-14 | 2009-07-15 | 112 | 69.95d | 0d | AD Radiation Technician | 8h |
| 114 | 2.2.2.1.12 | Install Drainage Ducts from Spouts to 55 Gal Barrrels | 1d | 2009-07-15 | 2009-07-16 | 113 | 69.95d |  | AD Mechanical Technician | 8h |
| 115 | 2.2.2.1.13 | Re-run any 110/220/480 Lines to Final Location | 1d | 2009-06-24 | 2009-06-24 | 105 | 19.75d | 0d | Electricians [400%]; AD Mechanical Technician [50%] | 36h |
| 116 | 2.2.2.1.14 | Extend any Cabling as Necessary | 1d | 2009-06-25 | 2009-06-25 | 115 | 19.75d | 0d | Electricians [400%]; AD Mechanical Technician [50%] | 36h |
| 117 | 2.2.2.1.15 | Mount Cable Tray in Final Location | 2d | 2009-06-26 | 2009-06-29 | 116 | 19.75d | 0d | Electricians [400%]; AD Mechanical Technician [50%] | 72h |
| 118 | 2.2.2.1.16 | Remove 55 Gal Barrels from MI-10 Work Zone | 1d | 2009-06-30 | 2009-06-30 | 117 | 19.75d | 0d | AD Mechanical Technician | 8h |
| 119 | 2.2.2.1.17 | Remove Drainage Ducts from Spouts | 0.25d | 2009-07-01 | 2009-07-01 | 118 | 19.75d | 0d | AD Mechanical Technician | 2h |
| 120 | 2.2.2.1.18 | Remove 8 Drain Spouts | 1d | 2009-07-01 | 2009-07-02 | 119 | 19.75d | 0d | AD Mechanical Technician | 8h |
| 121 | 2.2.2.1.19 | Cleanup Ceiling | 0.5d | 2009-07-02 | 2009-07-02 | 120 | 19.75d | 0d | AD Mechanical Technician | 4h |
| 122 | 2.2.2.1.20 | Install 14 Shield Covers on Ceiling Penetrations | 2d | 2009-07-02 | 2009-07-07 | 121 | 19.75d | 0d | AD Mechanical Technician | 16h |
| 123 | 2.2.2.1.21 | Fill 14 Conduits with Plastic Beads | 2d | 2009-07-07 | 2009-07-09 | 122 | 19.75d | 0d | AD Mechanical Technician | 16h |
| 124 | 2.2.2.1.22 | Cleanup any Major Mess in Barrier Zone | 1d | 2009-07-09 | 2009-07-10 | 123 | 19.75d | 0d | AD Mechanical Technician | 8h |
| 125 | 2.2.2.1.23 | Remove Barrier Walls | 1d | 2009-07-10 | 2009-07-13 | 124 | 19.75d | 0d | AD Mechanical Technician | 8h |
| 126 | 2.2.2.1.24 | Remove Ventilation Hose | 0.25d | 2009-07-13 | 2009-07-13 | 125 | 19.75d | 0d | AD Mechanical Technician | 2h |
| 127 | 2.2.2.1.25 | Remove Ventilation Fan | 0.25d | 2009-07-14 | 2009-07-14 | 126 | 19.75d | 0d | AD Mechanical Technician | 2h |
| 128 | 2.2.2.1.26 | Cleanup any Remaining Concrete Dust in Barrier Zone | 1d | 2009-07-14 | 2009-07-15 | 127 | 19.75d | 0d | AD Mechanical Technician | 8h |
| 129 | 2.2.2.1.27 | Remove Herculite from Recycler Beamline | 1d | 2009-07-15 | 2009-07-16 | 128 | 19.75d | 0d | AD Mechanical Technician | 8h |
| 130 | 2.2.2.1.28 | Remove Herculite from MI Beamline | 1d | 2009-07-16 | 2009-07-17 | 129 | 19.75d | 0d | AD Mechanical Technician | 8h |
| 131 | 2.2.2.1.29 | Remove Lead Blankets from Magnets | 1d | 2009-07-17 | 2009-07-20 | 130 | 19.75d | 0d | AD Mechanical Technician | 8h |
| 132 | 2.2.2.1.30 | Remove Lead Blanket Support Stands from Magnets | 1d | 2009-07-20 | 2009-07-21 | 131 | 19.75d | 0d | AD Mechanical Technician | 8h |
| 133 | 2.2.2.1.31 | Cleanup any Remaining Concrete Dust from Work Zone | 1d | 2009-07-21 | 2009-07-22 | 132 | 19.75d | 0d | AD Mechanical Technician | 8h |
| 134 | 2.2.2.1.32 | Align MI & RR Q102 to Q108 | 3d | 2009-07-22 | 2009-07-27 | 133 | 19.75d |  | PPD Survey | 24h |
| 135 | 2.2.2.1.33 | Fermilab Grade Survey Prior to Beam Turn-on | 1d | 2009-10-07 | 2009-10-08 | 164 | -32.95d | 0d |  |  |

| ID | WBS | Task | Duration | Start | Finish | Predecessors | Total slack | Free slack |
| --- | --- | --- | --- | --- | --- | --- | --- | --- |
| 136 | 2.2.2.2 | **Contractor @ MI-14** | 80.95d | 2009-06-15 | 2009-10-07 |  | -7d | 0d |
| 137 | 2.2.2.2.1 | **Conduit Installation** | 60.95d | 2009-06-15 | 2009-09-09 |  | -21.95d | 0d |
| 138 | 2.2.2.2.1.1 | Install Erosion Control | 1d | 2009-06-15 | 2009-06-15 | 13, 180 | -7d | 0d |
| 139 | 2.2.2.2.1.2 | Clear & Grub | 2d | 2009-06-16 | 2009-06-17 | 138 | -7d | 0d |
| 140 | 2.2.2.2.1.3 | Strip & Stockpile Topsoil | 2d | 2009-06-18 | 2009-06-19 | 139 | -7d | 0d |
| 141 | 2.2.2.2.1.4 | Excavation of Berm Above Q103 to Q107 | 5d | 2009-07-28 | 2009-08-04 | 140, 81 | -32.95d | 0d |
| 142 | 2.2.2.2.1.5 | Coring of 14 Holes in Ceiling | 10d | 2009-08-04 | 2009-08-18 | 141 | -32.95d | 0d |
| 143 | 2.2.2.2.1.6 | Install Support Frames | 10d | 2009-08-04 | 2009-08-18 | 142SS | -21.95d | 0d |
| 144 | 2.2.2.2.1.7 | Installation of 14 Conduits | 10d | 2009-08-11 | 2009-08-25 | 143SS+5d | -21.95d | 0d |
| 145 | 2.2.2.2.1.8 | FBP Enclosure Cap Beams | 5d | 2009-08-11 | 2009-08-18 | 144SS | -21.95d | 0d |
| 146 | 2.2.2.2.1.9 | Waterproof of Top of Enclosure | 5d | 2009-08-18 | 2009-08-25 | 145 | -21.95d | 0d |
| 147 | 2.2.2.2.1.10 | Backfilling of Berm Above Q103 to Q107 | 10d | 2009-08-25 | 2009-09-09 | 146 | -21.95d | 0d |
| 148 | 2.2.2.2.2 | **Concrete Foundation Installation** | 20d | 2009-08-25 | 2009-09-23 |  | -21.95d | 0d |
| 149 | 2.2.2.2.2.1 | FBP Deep Footing | 5d | 2009-08-25 | 2009-09-01 | 147SS | -21.95d | 0d |
| 150 | 2.2.2.2.2.2 | FBP Deep Wall | 5d | 2009-09-01 | 2009-09-09 | 149 | -21.95d | 0d |
| 151 | 2.2.2.2.2.3 | FBP Remaining Footings | 5d | 2009-09-01 | 2009-09-09 | 150SS | -21.95d | 0d |
| 152 | 2.2.2.2.2.4 | FBP Remaining Walls | 5d | 2009-09-09 | 2009-09-16 | 151 | -21.95d | 0d |
| 153 | 2.2.2.2.2.5 | FBP Transformer Foundation | 5d | 2009-09-09 | 2009-09-16 | 152SS | -21.95d | 0d |
| 154 | 2.2.2.2.2.6 | FBP Air Switch Foundation | 5d | 2009-09-09 | 2009-09-16 | 153SS | 26.5d |  |
| 155 | 2.2.2.2.2.7 | Backfill & Install Under Slab Conduits | 5d | 2009-09-09 | 2009-09-16 | 153SS | -21.95d | 0d |
| 156 | 2.2.2.2.2.8 | FBP Floor Slab | 5d | 2009-09-16 | 2009-09-23 | 155 | -21.95d | 0d |
| 157 | 2.2.2.2.2.9 | Construction of Foundations & Floor Slabs for MI-14 Bldg | 10d | 2009-08-25 | 2009-09-09 | 147SS | -11.95d | 0d |
| 158 | 2.2.2.2.3 | **Utility Installation** | 45d | 2009-08-04 | 2009-10-07 |  | -32.95d | 0d |
| 159 | 2.2.2.2.3.1 | Install Communication Handholes & Ductbank | 10d | 2009-08-04 | 2009-08-18 | 142SS | -32.95d | 0d |
| 160 | 2.2.2.2.3.2 | Install Power Manholes & Ductbank | 15d | 2009-08-04 | 2009-08-25 | 159SS | -32.95d | 0d |
| 161 | 2.2.2.2.3.3 | Install ICW Piping | 10d | 2009-08-25 | 2009-09-09 | 160 | -22.95d | 0d |
| 162 | 2.2.2.2.3.4 | Reroute ICW Piping | 10d | 2009-08-25 | 2009-09-09 | 161SS | -22.95d | 0d |
| 163 | 2.2.2.2.3.5 | Install HV Feeder Cable & Terminate | 20d | 2009-08-25 | 2009-09-23 | 160 | -32.95d | 0d |
| 164 | 2.2.2.2.3.6 | Install Hardstand | 10d | 2009-09-23 | 2009-10-07 | 162, 163 | -32.95d | 0d |

| ID | WBS | Task | Type | Duration | Start | Finish | Predecessors | Total slack | Free slack | Constraint | Resources | Work |
| --- | --- | --- | --- | --- | --- | --- | --- | --- | --- | --- | --- | --- |
| 165 | 2.2.3 | **MI-60 Service Building** |  | 30d | 2009-06-22 | 2009-08-03 |  | 14d |  |  |  |  |
| 166 | 2.2.3.1 | **Concrete Foundation Installation** |  | 20d | 2009-07-07 | 2009-08-03 |  | 14d |  |  |  |  |
| 167 | 2.2.3.1.1 | FBP air switch foundation |  | 5d | 2009-07-07 | 2009-07-13 | 175 | 24d | 0d |  |  |  |
| 168 | 2.2.3.1.2 | FBP disconnect switch foundation |  | 5d | 2009-07-07 | 2009-07-13 | 175 | 24d | 0d |  |  |  |
| 169 | 2.2.3.1.3 | FBP transformer foundation |  | 5d | 2009-07-14 | 2009-07-20 | 168, 167 | 24d |  |  |  |  |
| 170 | 2.2.3.1.4 | FBP building footings |  | 10d | 2009-07-07 | 2009-07-20 | 175 | 14d | 0d |  |  |  |
| 171 | 2.2.3.1.5 | FBP buiding foudation walls |  | 5d | 2009-07-14 | 2009-07-20 | 170SS+5d | 14d | 0d |  |  |  |
| 172 | 2.2.3.1.6 | FBP building floor slab |  | 5d | 2009-07-21 | 2009-07-27 | 171 | 14d | 0d |  |  |  |
| 173 | 2.2.3.1.7 | FBP concrete drainage apron |  | 5d | 2009-07-28 | 2009-08-03 | 172 | 14d |  |  |  |  |
| 174 | 2.2.3.2 | **Utility Installation** |  | 10d | 2009-06-22 | 2009-07-06 |  | 14d |  |  |  |  |
| 175 | 2.2.3.2.1 | Install power ductbank |  | 10d | 2009-06-22 | 2009-07-06 | 80 | 14d | 0d |  |  |  |
| 176 | 3 | **LCW System** |  | 5d | 2009-06-22 | 2009-06-26 |  | 39d |  |  |  | 167h |
| 177 | 3.1 | I&E for LCW Routing in Future |  | 1d | 2009-06-22 | 2009-06-22 | 2 | 39d | 0d |  | AD Mechanical Engineer; AD Mechanical Drafter | 16h |
| 178 | 3.2 | Install Taps in LCW Headers for Future LCW lines |  | 4d | 2009-06-23 | 2009-06-26 | 177 | 39d |  |  | AD Mechanical Technician [150%]; Pipe Fitters [300%]; AD Mechanical Engineer [21.9%] | 151h |
| 179 | 4 | **Management** |  | 92.45d | 2009-06-15 | 2009-10-23 |  | -43.45d | 0d |  |  |  |
| 180 | 4.1 | Start FY09 Shutdown | milestone | 0d | 2009-06-15 | 2009-06-15 |  | -43.45d | 0d | start no earlier than 2009-06-15 |  |  |
| 181 | 4.2 | FY09 Shutdown Complete | milestone | 0d | 2009-10-23 | 2009-10-23 | 180FF+50d, 5, 6, 7, 8, 178, 23, 24, 94, 156, 135, 169, 173, 75, 95, 157, 134 | -43.45d | 0d | finish no later than 2009-08-23 |  |  |
